# 416_Prog Lav

Schedule from MS Project, 2018-01-01 to 2023-06-28, status date 2016-09-29.
A.I.G. Associati

## Calendars

- senza festivi: Mon-Sun 08:00-12:00, 13:00-17:00.

## Schedule

| ID | WBS | Task | Type | Duration | Start | Finish | Predecessors | Total slack | Constraint | Text1 |
| --- | --- | --- | --- | --- | --- | --- | --- | --- | --- | --- |
| 1 | 1 | **Lieferung und Montage der Zentralsterilization / Fornitura e montaggio della Centrale di Sterilizzazione** |  | 2005d | 2018-01-01 | 2023-06-28 |  | 0d | start no earlier than 2016-04-30 |  |
| 2 | 1.1 | **Frist für die fertigstellung der Lieferung / Tempo utile per l’ultimazione della fornitura** |  | 1093d | 2018-01-01 | 2020-12-28 |  | 0d |  |  |
| 3 | 1.1.1 | **Erster Teil der Lieferung / Prima consegna** |  | 242d | 2018-01-01 | 2018-08-30 |  | 0d |  |  |
| 4 | 1.1.1.1 | Zeitpunkt 0: Beginn der Ausführung des Vetrags / Tempo 0: Avvio dell'esecuzione del contratto | milestone | 1d | 2018-01-01 | 2018-01-01 |  | 0d | start no earlier than 2018-01-01 |  |
| 5 | 1.1.1.2 | Konstruktionsplan / Progettazione costruttiva |  | 90d | 2018-01-02 | 2018-04-01 | 4 | 0d | start no earlier than 2017-07-01 |  |
| 6 | 1.1.1.3 | Bestätigung Konstruktionsplan / Approvazione costruttivo | milestone | 30d | 2018-04-02 | 2018-05-01 | 5 | 0d | start no earlier than 2017-10-01 |  |
| 7 | 1.1.1.4 | Vorbereitung der Lieferung Phase 1 / Preparazione fornitura Fase 1 |  | 60d | 2018-05-02 | 2018-06-30 | 6 | 0d | start no earlier than 2017-11-01 |  |
| 8 | 1.1.1.5 | Vorarbeiten zur Installation der zu liefernden Geraete und Montage der Unterkonstruktionen / Predisposizoni alle installazioni delle attrezzature da fornire e montaggio delle sottostrutture |  | 60d | 2018-07-01 | 2018-08-29 | 7 | 0d |  |  |
| 9 | 1.1.1.6 | Zeitpunkt Phase 1 / Tempo FASE 1 | milestone | 1d | 2018-08-30 | 2018-08-30 | 8 | 0d | start no earlier than 2014-10-15 |  |
| 10 | 1.1.2 | **Zweiter Teil der Lieferung / Seconda consegna** |  | 851d | 2018-08-31 | 2020-12-28 | 9 | 0d |  |  |
| 11 | 1.1.2.1 | Vorbereitung der Lieferung Phase 2 / Preparazione fornitura Fase 2 |  | 120d | 2018-08-31 | 2020-09-28 | 9 | 0d | finish no earlier than 2020-03-31 |  |
| 12 | 1.1.2.2 | Montage der zu liefernden Geräte / Montaggio delle attrezzature da fornire |  | 90d | 2020-09-29 | 2020-12-27 | 11 | 0d |  |  |
| 13 | 1.1.2.3 | Zeitpunkt Phase 2 / Tempo FASE 2 | milestone | 1d | 2020-12-28 | 2020-12-28 | 12 | 0d |  |  |
| 14 | 1.2 | Endabnahme / Collaudo finale |  | 180d | 2020-12-29 | 2021-06-26 | 13 | 0d |  |  |
| 15 | 1.3 | Zeitpunkt Phase 3 / Tempo FASE 3 | milestone | 1d | 2021-06-27 | 2021-06-27 | 14 | 0d |  |  |
| 16 | 1.4 | Abschluss der Bauarbeiten der Klinik / Ultimazione Lavori di realizzazione della Clinica |  | 730d | 2021-06-28 | 2023-06-27 | 15 | 0d |  | Max. 2 anni/Jahren |
| 17 | 1.5 | Beginninung der Garantiedauer von zwei Jahren / Inizio Validità garanzia di due anni | milestone | 1d | 2023-06-28 | 2023-06-28 | 16 | 0d |  |  |
